# PROTECCIÓN Y ENCAUZAMIENTO - CUENCA CAÑETE

Schedule from Primavera P6, 2024-06-17 to 2025-07-01, data date 2024-06-17.
Must finish by 2025-07-02

## Calendars

- Primavera P6 - Perú: Mon-Sat 08:00-12:00, 13:00-17:00; Sun off.

## Schedule

| ID | WBS | Activity | Duration | Start | Finish | Predecessors | Total float | Free float |
| --- | --- | --- | --- | --- | --- | --- | --- | --- |
|  | 1 | **OBRAS PROVISIONALES** |  | 2024-06-17 | 2024-07-13 |  |  |  |
| A1000 |  | Campamento Provisional de Obra | 3d | 2024-06-17 | 2024-06-19 |  | 211d | 0d |
| A1010 |  | Movilización y Desmovilización de maquinaria pesada | 7d | 2024-06-17 | 2024-06-24 |  | 0d |  |
| A1020 |  | Mejoramiento y Habilitación de caminos de acceso | 10d | 2024-06-25 | 2024-07-05 | A1010 | 39d | 0d |
| A1030 |  | Limpieza manual de material vegetal y de residuos | 5d | 2024-07-01 | 2024-07-05 | A1020 FF | 304d | 0d |
| A1040 |  | Mantenimiento de caminos de acceso | 5d | 2024-07-01 | 2024-07-05 | A1030 FF | 304d | 0d |
| A1050 |  | Habilitación de plataformas | 5d | 2024-07-06 | 2024-07-11 | A1040 | 304d |  |
|  | 1 | **Demolición** |  | 2024-06-25 | 2024-07-13 |  |  |  |
| A2260 |  | Demolicion de Canales en Qdas. | 16d | 2024-06-25 | 2024-07-12 | A1010 | 0d |  |
| A2270 |  | Demolicion de Baden | 3d | 2024-06-25 | 2024-06-27 | A2260 SS | 306d | 0d |
| A2280 |  | Demolicion de Pavimentos | 7d | 2024-06-28 | 2024-07-05 | A2270 | 306d | 0d |
| A2310 |  | Eliminacion de material de demolicion | 13d | 2024-06-29 | 2024-07-13 | A2260 SS+4d | 302d |  |
| A2290 |  | Demolicion de Veredas | 1d | 2024-07-06 | 2024-07-06 | A2280 | 306d | 0d |
| A2300 |  | Demolicion de Cerco Perimétrico | 2d | 2024-07-08 | 2024-07-09 | A2290 | 306d |  |
|  | 2 | **TOPOGRAFÍA** |  | 2024-06-20 | 2024-06-24 |  |  |  |
| A1130 |  | Trazo y replanteo inicial | 4d | 2024-06-20 | 2024-06-24 | A1000 | 211d | 0d |
|  | 3 | **MOVIMIENTO DE TIERRAS** |  | 2024-06-25 | 2024-10-28 |  |  |  |
| A1140 |  | Desbroce | 10d | 2024-06-25 | 2024-07-05 | A1130 | 211d | 0d |
| A1180 |  | Conformación de material excedente en DME | 16d | 2024-06-25 | 2024-07-12 | A2260 SS | 28d | 0d |
| A1190 |  | Conformación de material excedente en DMO | 10d | 2024-06-25 | 2024-07-05 | A1140 SS | 264d | 0d |
| A1150 |  | Excavación de cimentación | 100d | 2024-06-28 | 2024-10-22 | A1140 SS+3d | 211d | 0d |
| A1160 |  | Perfilado y conformación de Plataforma de fundación | 100d | 2024-07-04 | 2024-10-28 | A1150 SS+5d | 211d | 0d |
| A1200 |  | Relleno con material granular | 70d | 2024-07-04 | 2024-09-23 | A1160 SS | 211d | 0d |
| A2320 |  | Suministro de Roca | 60d | 2024-07-06 | 2024-09-13 | A1020 | 39d | 0d |
| A2330 |  | Colocación de Roca en Uña | 20d | 2024-07-12 | 2024-08-03 | A2320 SS+5d | 254d | 0d |
| A2340 |  | Roca Recebada | 30d | 2024-08-05 | 2024-09-07 | A2330 | 254d |  |
| A1210 |  | Relleno Estructural | 30d | 2024-09-24 | 2024-10-28 | A1200 | 211d | 0d |
| A2350 |  | Subbase granular | 20d | 2024-09-30 | 2024-10-22 | A1210 SS+5d | 216d | 0d |
| A2360 |  | Emboquillado de piedra | 10d | 2024-10-11 | 2024-10-22 | A2350 FF | 216d |  |

| ID | WBS | Activity | Duration | Start | Finish | Predecessors | Total float | Free float |
| --- | --- | --- | --- | --- | --- | --- | --- | --- |
|  | 4 | **ESTRUCTURAS CANALIZADAS** |  | 2024-07-10 | 2024-10-03 |  |  |  |
|  | 1 | **Obras de Concreto Simple** |  | 2024-07-10 | 2024-09-17 |  |  |  |
| A2380 |  | CONCRETO CLASE A (F'C=280 KG/CM2) PREMEZCLADO | 60d | 2024-07-10 | 2024-09-17 | A2410 FF | 0d |  |
| A2370 |  | CONCRETO CLASE F(F'C=100 KG/CM2) | 30d | 2024-07-13 | 2024-08-16 | A2260 | 0d |  |
| A2410 |  | ENCOFRADO Y DESENCOFRADO | 50d | 2024-07-22 | 2024-09-17 | A2370 SS+7d | 0d |  |
|  | 2 | **Obras de Concreto Armado** |  | 2024-07-18 | 2024-10-03 |  |  |  |
| A2430 |  | CONCRETO CLASE A (F'C=280 KG/CM2) | 60d | 2024-07-18 | 2024-09-25 | A2480 SS | 0d |  |
| A2440 |  | ENCOFRADO Y DESENCOFRADO | 60d | 2024-07-18 | 2024-09-25 | A2380 SS+7d | 0d |  |
| A2460 |  | ACERO FY=4200 KG/CM2, GRADO 60 | 60d | 2024-07-18 | 2024-09-25 | A2440 SS | 0d |  |
| A2470 |  | GEOCOMPUESTO DE DRENAJE | 60d | 2024-07-18 | 2024-09-25 | A2460 SS | 0d |  |
| A2480 |  | TUBOS PVC | 60d | 2024-07-18 | 2024-09-25 | A2470 SS | 0d |  |
| A2500 |  | JUNTA DE DILATACIÓN | 50d | 2024-08-07 | 2024-10-03 | A2430 FF+7d | 232d |  |
|  | 5 | **INTERFERENCIAS** |  | 2024-09-26 | 2025-05-28 |  |  |  |
|  | 1 | **Interferencias Tipo Tubería** |  | 2024-09-26 | 2024-11-16 |  |  |  |
|  | 1 | **Trabajos Preliminares** |  | 2024-09-26 | 2024-10-03 |  |  |  |
| A2510 |  | LIMPIEZA MANUAL DE TERRENO | 2d | 2024-09-26 | 2024-09-27 | A2430 | 0d |  |
| A2520 |  | TRAZO Y REPLANTEO PRELIMINAR | 2d | 2024-09-28 | 2024-09-30 | A2510 | 0d |  |
| A2530 |  | DESVÍO PROVISIONAL CON TUBERÍA | 3d | 2024-10-01 | 2024-10-03 | A2520 | 0d |  |
|  | 2 | **Movimiento de Tierras** |  | 2024-10-04 | 2024-11-16 |  |  |  |
| A2540 |  | EXCAVACION NO CLASIFICADA | 18d | 2024-10-04 | 2024-10-24 | A2530 | 0d |  |
| A2560 |  | NIVELACION INTERIOR Y APISONADO CON EQUIPO | 12d | 2024-10-12 | 2024-10-25 | A2540 SS+7d | 0d |  |
| A2570 |  | RELLENO ESTRUCTURAL COMPACTADO | 30d | 2024-10-14 | 2024-11-16 | A2560 SS+1d | 0d |  |
| A2580 |  | ACARREO DE MATERIAL EXCEDENTE | 5d | 2024-10-25 | 2024-10-30 | A2540 | 209d |  |
|  | 3 | **Obras de Concreto Simple** |  | 2024-10-22 | 2024-10-30 |  |  |  |
| A2590 |  | CONCRETO CLASE F(F'C=100 KG/CM2) - SOLADOS | 8d | 2024-10-22 | 2024-10-30 | A2570 SS+7d | 197d | 0d |

| ID | WBS | Activity | Duration | Start | Finish | Predecessors | Total float | Free float |
| --- | --- | --- | --- | --- | --- | --- | --- | --- |
|  | 4 | **Obras de Concreto Armado** |  | 2024-10-30 | 2024-11-13 |  |  |  |
| A2620 |  | ENCOFRADO Y DESENCOFRADO | 8d | 2024-10-30 | 2024-11-07 | A2590 SS+7d | 197d | 0d |
| A2630 |  | ACERO FY=4200 KG/CM2, GRADO 60 | 8d | 2024-10-30 | 2024-11-07 | A2620 FF | 197d | 0d |
| A2640 |  | CABLES DE ACERO | 8d | 2024-10-30 | 2024-11-07 | A2630 FF | 197d | 0d |
| A2650 |  | GEOCOMPUESTO DE DRENAJE | 8d | 2024-10-30 | 2024-11-07 | A2640 FF | 197d | 0d |
| A2660 |  | TUBO PVC | 8d | 2024-10-30 | 2024-11-07 | A2650 FF | 197d | 0d |
| A2600 |  | CONCRETO CLASE A (F'C=280 KG/CM2) | 8d | 2024-10-31 | 2024-11-08 | A2660 SS+1d | 197d | 0d |
| A2670 |  | JUNTA DE DILATACIÓN | 4d | 2024-11-09 | 2024-11-13 | A2600 | 197d | 0d |
|  | 5 | **Carpintería Metálica** |  | 2024-11-09 | 2024-11-11 |  |  |  |
| A2680 |  | SOPORTE METÁLICO TIPO L | 2d | 2024-11-09 | 2024-11-11 | A2600 | 199d |  |
|  | 6 | **Instalaciones Hidráulicas** |  | 2024-10-31 | 2024-11-01 |  |  |  |
| A2690 |  | ACCESORIOS SANITARIOS | 2d | 2024-10-31 | 2024-11-01 | A2660 SS+1d | 207d |  |
|  | 7 | **Arquitectura** |  | 2024-11-09 | 2024-11-12 |  |  |  |
| A2700 |  | PINTURA BITUMINOSA | 3d | 2024-11-09 | 2024-11-12 | A2670 SS | 198d |  |
|  | 2 | **Interferencias Tipo Ducto** |  | 2024-11-18 | 2024-12-28 |  |  |  |
|  | 1 | **Trabajos Preliminares** |  | 2024-11-18 | 2024-11-25 |  |  |  |
| A2710 |  | LIMPIEZA MANUAL DE TERRENO | 2d | 2024-11-18 | 2024-11-19 | A2570 | 0d |  |
| A2720 |  | TRAZO Y REPLANTEO PRELIMINAR | 2d | 2024-11-20 | 2024-11-21 | A2710 | 0d |  |
| A2730 |  | DESVÍO PROVISIONAL CON TUBERÍA | 3d | 2024-11-22 | 2024-11-25 | A2720 | 0d |  |
|  | 2 | **Movimiento de Tierras** |  | 2024-11-26 | 2024-12-28 |  |  |  |
| A2740 |  | EXCAVACION NO CLASIFICADA | 23d | 2024-11-26 | 2024-12-21 | A2730 | 0d |  |
| A2760 |  | NIVELACION INTERIOR Y APISONADO CON EQUIPO | 19d | 2024-12-04 | 2024-12-25 | A2740 SS+7d | 0d |  |
| A2770 |  | RELLENO ESTRUCTURAL COMPACTADO | 3d | 2024-12-05 | 2024-12-07 | A2760 SS+1d | 0d |  |
| A2780 |  | ACARREO DE MATERIAL EXCEDENTE | 6d | 2024-12-23 | 2024-12-28 | A2740 | 158d |  |

| ID | WBS | Activity | Duration | Start | Finish | Predecessors | Total float | Free float |
| --- | --- | --- | --- | --- | --- | --- | --- | --- |
|  | 3 | **Obras de Concreto Simple** |  | 2024-12-09 | 2024-12-10 |  |  |  |
| A2790 |  | CONCRETO CLASE F(F'C=100 KG/CM2) - SOLADOS | 2d | 2024-12-09 | 2024-12-10 | A2770 | 163d | 0d |
| A2810 |  | EMBOQUILLADO DE PIEDRA F'C=175KG/CM2 e=0.30m | 2d | 2024-12-09 | 2024-12-10 | A2790 FF | 174d |  |
|  | 4 | **Obras de Concreto Armado** |  | 2024-12-11 | 2024-12-17 |  |  |  |
| A2800 |  | CONCRETO CLASE B (F'C=280 KG/CM2) | 6d | 2024-12-11 | 2024-12-17 | A2830 FF | 163d | 0d |
| A2820 |  | ENCOFRADO Y DESENCOFRADO | 6d | 2024-12-11 | 2024-12-17 | A2790 | 163d | 0d |
| A2830 |  | ACERO FY=4200 KG/CM2, GRADO 60 | 6d | 2024-12-11 | 2024-12-17 | A2820 FF | 163d | 0d |
| A2840 |  | TAPA DE CONCRETO PREFABRICADA | 2d | 2024-12-16 | 2024-12-17 | A2800 FF | 168d |  |
|  | 5 | **Instalaciones Hidráulicas** |  | 2024-12-18 | 2024-12-20 |  |  |  |
| A2850 |  | JUNTA WATERSTOP | 2d | 2024-12-18 | 2024-12-19 | A2800 | 163d | 0d |
| A2860 |  | COMPUERTA PLANA TIPO TARJETA 0.50m*0.50m | 1d | 2024-12-20 | 2024-12-20 | A2850 | 165d |  |
|  | 6 | **Arquitectura** |  | 2024-12-20 | 2024-12-23 |  |  |  |
| A2870 |  | PINTURA BITUMINOSA | 3d | 2024-12-20 | 2024-12-23 | A2850 | 163d |  |
|  | 3 | **Interferencias Tipo Sifones** |  | 2024-12-09 | 2025-04-11 |  |  |  |
|  | 1 | **Trabajos Preliminares** |  | 2024-12-09 | 2024-12-16 |  |  |  |
| A2880 |  | LIMPIEZA MANUAL DE TERRENO | 2d | 2024-12-09 | 2024-12-10 | A2770 | 0d |  |
| A2890 |  | TRAZO Y REPLANTEO PRELIMINAR | 2d | 2024-12-11 | 2024-12-12 | A2880 | 0d |  |
| A2900 |  | DESVÍO PROVISIONAL CON TUBERÍAS | 3d | 2024-12-13 | 2024-12-16 | A2890 | 0d |  |
|  | 2 | **Movimiento de Tierras** |  | 2024-12-17 | 2025-04-11 |  |  |  |
| A2910 |  | EXCAVACION NO CLASIFICADA | 40d | 2024-12-17 | 2025-01-31 | A2900 | 0d |  |
| A2920 |  | NIVELACION INTERIOR Y APISONADO CON EQUIPO | 34d | 2024-12-25 | 2025-02-01 | A2910 SS+7d | 0d |  |
| A2930 |  | CAMA DE APOYO CON ARENA E=0.20m | 20d | 2024-12-26 | 2025-01-17 | A2920 SS+1d | 0d |  |
| A2940 |  | RELLENO ESTRUCTURAL COMPACTADO | 60d | 2024-12-26 | 2025-03-05 | A2930 SS | 0d |  |
| A2950 |  | ACARREO DE MATERIAL EXCEDENTE | 60d | 2025-02-01 | 2025-04-11 | A2910 | 69d |  |

| ID | WBS | Activity | Duration | Start | Finish | Predecessors | Total float | Free float |
| --- | --- | --- | --- | --- | --- | --- | --- | --- |
|  | 3 | **Obras de Concreto Simple** |  | 2025-01-03 | 2025-01-14 |  |  |  |
| A2960 |  | CONCRETO CLASE F(F'C=100 KG/CM2) | 5d | 2025-01-03 | 2025-01-08 | A2940 SS+7d | 121d | 0d |
| A2970 |  | EMBOQUILLADO DE PIEDRA F'C=175KG/CM2 e=0.30m | 5d | 2025-01-09 | 2025-01-14 | A2960 | 144d |  |
|  | 4 | **Obras de Concreto Armado** |  | 2025-01-09 | 2025-01-30 |  |  |  |
| A2980 |  | CONCRETO CLASE A (F'C=280 KG/CM2) | 14d | 2025-01-09 | 2025-01-24 | A3000 FF | 121d | 0d |
| A2990 |  | ENCOFRADO Y DESENCOFRADO | 14d | 2025-01-09 | 2025-01-24 | A2960 | 121d | 0d |
| A3000 |  | ACERO FY=4200 KG/CM2, GRADO 60 | 14d | 2025-01-09 | 2025-01-24 | A2990 FF | 121d | 0d |
| A3010 |  | TAPA DE CONCRETO PREFABRICADA | 5d | 2025-01-25 | 2025-01-30 | A2980 | 125d | 0d |
| A3020 |  | JUNTA DE DILATACIÓN | 5d | 2025-01-25 | 2025-01-30 | A3010 SS | 125d | 0d |
|  | 5 | **Carpintería Metálica** |  | 2025-02-03 | 2025-02-10 |  |  |  |
| A3030 |  | REJILLAS METÁLICAS | 3d | 2025-02-03 | 2025-02-05 | A2980 FS+7d | 121d | 0d |
| A3040 |  | ESCALERAS DE GATO | 2d | 2025-02-06 | 2025-02-07 | A3030 | 121d | 0d |
| A3050 |  | SOPORTES PARA ARNÉS | 2d | 2025-02-08 | 2025-02-10 | A3040 | 121d |  |
|  | 6 | **Instalaciones Hidráulicas** |  | 2025-01-31 | 2025-02-05 |  |  |  |
| A3060 |  | TUBERÍA HDPE | 3d | 2025-01-31 | 2025-02-03 | A3020 | 125d | 0d |
| A3070 |  | CODO HDPE | 3d | 2025-01-31 | 2025-02-03 | A3060 FF | 125d | 0d |
| A3080 |  | ACCESORIO RESTRICCIÓN AXIAL | 3d | 2025-01-31 | 2025-02-03 | A3070 FF | 125d | 0d |
| A3090 |  | JUNTA WATERSTOP | 3d | 2025-01-31 | 2025-02-03 | A3080 FF | 125d | 0d |
| A3100 |  | SALIDA HDPE | 3d | 2025-01-31 | 2025-02-03 | A3090 FF | 125d | 0d |
| A3110 |  | VÁLVULAS COMPUERTA | 3d | 2025-01-31 | 2025-02-03 | A3100 FF | 125d | 0d |
| A3120 |  | ACCESORIOS (UNIONES, NIPLES, FLANGES, BACKIN RINGS) | 3d | 2025-01-31 | 2025-02-03 | A3110 FF | 125d | 0d |
| A3130 |  | CÁMARA DE CONCRETO | 2d | 2025-02-04 | 2025-02-05 | A3120 | 125d | 0d |
| A3140 |  | COMPUERTAS TIPO TARJETA | 1d | 2025-02-05 | 2025-02-05 | A3130 FF | 125d |  |
|  | 7 | **Arquitectura** |  | 2025-01-31 | 2025-02-05 |  |  |  |
| A3150 |  | PINTURA BITUMINOSA | 5d | 2025-01-31 | 2025-02-05 | A3020 | 125d |  |

| ID | WBS | Activity | Duration | Start | Finish | Predecessors | Total float | Free float |
| --- | --- | --- | --- | --- | --- | --- | --- | --- |
|  | 4 | **Canales** |  | 2025-03-06 | 2025-04-23 |  |  |  |
|  | 1 | **Trabajos Preliminares** |  | 2025-03-06 | 2025-03-13 |  |  |  |
| A3160 |  | LIMPIEZA MANUAL DE TERRENO | 2d | 2025-03-06 | 2025-03-07 | A2940 | 0d |  |
| A3170 |  | TRAZO Y REPLANTEO PRELIMINAR | 2d | 2025-03-08 | 2025-03-10 | A3160 | 0d |  |
| A3180 |  | DESVÍO PROVISIONAL EN TIERRA | 3d | 2025-03-11 | 2025-03-13 | A3170 | 0d |  |
|  | 2 | **Movimiento de Tierras** |  | 2025-03-14 | 2025-04-23 |  |  |  |
| A3190 |  | EXCAVACION NO CLASIFICADA | 20d | 2025-03-14 | 2025-04-05 | A3180 | 0d |  |
| A3200 |  | NIVELACION INTERIOR Y APISONADO CON EQUIPO | 14d | 2025-03-22 | 2025-04-07 | A3190 SS+7d | 0d |  |
| A3210 |  | RELLENO ESTRUCTURAL COMPACTADO | 1d | 2025-03-24 | 2025-03-24 | A3200 SS+1d | 0d |  |
| A3220 |  | ACARREO DE MATERIAL EXCEDENTE | 15d | 2025-04-07 | 2025-04-23 | A3190 | 59d |  |
|  | 3 | **Obras de Concreto Simple** |  | 2025-03-25 | 2025-04-01 |  |  |  |
| A3230 |  | ENCOFRADO Y DESENCOFRADO EN ESTRUCTURAS | 7d | 2025-03-25 | 2025-04-01 | A3210 | 65d | 0d |
| A3240 |  | EMBOQUILLADO DE PIEDRA F'C=175KG/CM2 e=0.20m | 7d | 2025-03-25 | 2025-04-01 | A3230 FF | 65d | 0d |
|  | 4 | **Obras de Concreto Armado** |  | 2025-04-02 | 2025-04-04 |  |  |  |
| A3250 |  | CONCRETO CLASE A (F'C=280 KG/CM2) | 2d | 2025-04-02 | 2025-04-03 | A3270 FF | 65d | 0d |
| A3260 |  | ENCOFRADO Y DESENCOFRADO | 2d | 2025-04-02 | 2025-04-03 | A3240 | 65d | 0d |
| A3270 |  | ACERO FY=4200 KG/CM2, GRADO 60 | 2d | 2025-04-02 | 2025-04-03 | A3260 FF | 65d | 0d |
| A3280 |  | TAPA DE CONCRETO PREFABRICADA E=0.12m (F'C=280KG/CM2) | 1d | 2025-04-04 | 2025-04-04 | A3250 | 65d | 0d |
|  | 5 | **Instalaciones Hidráulicas** |  | 2025-04-05 | 2025-04-16 |  |  |  |
| A3290 |  | JUNTAS WATERSTOP | 10d | 2025-04-05 | 2025-04-16 | A3280 | 65d | 0d |
|  | 6 | **Arquitectura** |  | 2025-04-14 | 2025-04-16 |  |  |  |
| A3300 |  | PINTURA BITUMINOSA | 3d | 2025-04-14 | 2025-04-16 | A3290 FF | 65d |  |
|  | 5 | **Alcantarillas y Buzones** |  | 2025-03-25 | 2025-05-28 |  |  |  |
|  | 1 | **Trabajos Preliminares** |  | 2025-03-25 | 2025-04-02 |  |  |  |
| A3310 |  | LIMPIEZA MANUAL DE TERRENO | 2d | 2025-03-25 | 2025-03-26 | A3210 | 0d |  |
| A3320 |  | TRAZO Y REPLANTEO PRELIMINAR | 2d | 2025-03-27 | 2025-03-28 | A3310 | 0d |  |
| A3330 |  | DESVÍO PROVISIONAL CON TUBERÍA | 3d | 2025-03-29 | 2025-04-01 | A3320 | 0d |  |
| A3340 |  | DESMONTAJE DE TUBERIAS PVC Ø8" | 1d | 2025-04-02 | 2025-04-02 | A3330 | 0d |  |

| ID | WBS | Activity | Duration | Start | Finish | Predecessors | Total float | Free float |
| --- | --- | --- | --- | --- | --- | --- | --- | --- |
|  | 2 | **Movimiento de Tierras** |  | 2025-04-03 | 2025-05-05 |  |  |  |
| A3350 |  | EXCAVACION NO CLASIFICADA | 11d | 2025-04-03 | 2025-04-15 | A3340 | 0d |  |
| A3360 |  | NIVELACION INTERIOR Y APISONADO CON EQUIPO | 7d | 2025-04-11 | 2025-04-18 | A3350 SS+7d | 0d |  |
| A3370 |  | CAMA DE APOYO CON ARENA E=0.10m | 5d | 2025-04-11 | 2025-04-16 | A3360 SS | 0d |  |
| A3380 |  | RELLENO ESTRUCTURAL COMPACTADO | 20d | 2025-04-12 | 2025-05-05 | A3370 SS+1d | 0d |  |
| A3390 |  | ACARREO DE MATERIAL EXCEDENTE | 5d | 2025-04-16 | 2025-04-21 | A3350 | 61d |  |
|  | 3 | **Obras de Concreto Simple** |  | 2025-05-06 | 2025-05-10 |  |  |  |
| A3400 |  | CONCRETO CLASE F(F'C=100 KG/CM2) | 5d | 2025-05-06 | 2025-05-10 | A3410 FF | 29d | 0d |
| A3410 |  | ENCOFRADO Y DESENCOFRADO EN ESTRUCTURAS | 5d | 2025-05-06 | 2025-05-10 | A3380 | 29d | 0d |
| A3420 |  | EMBOQUILLADO DE PIEDRA F'C=175KG/CM2 | 5d | 2025-05-06 | 2025-05-10 | A3400 FF | 29d | 0d |
|  | 4 | **Obras de Concreto Armado** |  | 2025-05-12 | 2025-05-23 |  |  |  |
| A3430 |  | CONCRETO CLASE B (F'C=280 KG/CM2) | 10d | 2025-05-12 | 2025-05-22 | A3450 FF | 29d | 0d |
| A3440 |  | ENCOFRADO Y DESENCOFRADO CARA VISTA | 10d | 2025-05-12 | 2025-05-22 | A3420 | 29d | 0d |
| A3450 |  | ACERO FY=4200 KG/CM2, GRADO 60 | 10d | 2025-05-12 | 2025-05-22 | A3440 FF | 29d | 0d |
| A3460 |  | TAPA DE CONCRETO PREFABRICADA | 2d | 2025-05-21 | 2025-05-22 | A3430 FF | 33d | 0d |
| A3470 |  | JUNTA DE DILATACIÓN | 1d | 2025-05-23 | 2025-05-23 | A3460 | 33d |  |
|  | 5 | **Carpintería Metálica** |  | 2025-05-23 | 2025-05-24 |  |  |  |
| A3480 |  | MARCO Y TAPA DE HD CON DOBLE PESTILLO | 2d | 2025-05-23 | 2025-05-24 | A3430 | 32d | 0d |
| A3490 |  | ESCALERA DE GATO | 2d | 2025-05-23 | 2025-05-24 | A3480 FF | 32d | 0d |
| A3500 |  | SOPORTES P/ARNÉS DE SEGURIDAD | 2d | 2025-05-23 | 2025-05-24 | A3490 FF | 32d |  |
|  | 6 | **Instalaciones Hidráulicas** |  | 2025-05-23 | 2025-05-28 |  |  |  |
| A3510 |  | TUBERÍA PVC | 4d | 2025-05-23 | 2025-05-27 | A3430 | 29d | 0d |
| A3520 |  | JUNTA WATERSTOP | 3d | 2025-05-23 | 2025-05-26 | A3510 SS | 29d | 0d |
| A3530 |  | BUZON DE CONCRETO | 5d | 2025-05-23 | 2025-05-28 | A3520 SS | 29d |  |

| ID | WBS | Activity | Duration | Start | Finish | Predecessors | Total float | Free float |
| --- | --- | --- | --- | --- | --- | --- | --- | --- |
|  | 6 | **Badenes** |  | 2025-05-06 | 2025-05-28 |  |  |  |
|  | 1 | **Trabajos Preliminares** |  | 2025-05-06 | 2025-05-09 |  |  |  |
| A3540 |  | LIMPIEZA MANUAL DE TERRENO | 2d | 2025-05-06 | 2025-05-07 | A3380 | 0d |  |
| A3550 |  | TRAZO Y REPLANTEO PRELIMINAR | 2d | 2025-05-08 | 2025-05-09 | A3540 | 0d |  |
|  | 2 | **Movimiento de Tierras** |  | 2025-05-10 | 2025-05-14 |  |  |  |
| A3560 |  | Nivelacion interior y apisonado con equipo | 4d | 2025-05-10 | 2025-05-14 | A3550 | 0d |  |
|  | 3 | **Obras de Concreto Simple** |  | 2025-05-15 | 2025-05-23 |  |  |  |
| A3570 |  | Concreto Clase E (f'c=100 kg/cm2) concreto de nivelación | 8d | 2025-05-15 | 2025-05-23 | A3560 | 29d | 0d |
|  | 4 | **Obras de Concreto Armado** |  | 2025-05-24 | 2025-05-27 |  |  |  |
| A3580 |  | CONCRETO CLASE A (F'C=280 KG/CM2)- PREMEZCLADO-LOSA | 3d | 2025-05-24 | 2025-05-27 | A3600 FF | 29d | 0d |
| A3590 |  | ENCOFRADO Y DESENCOFRADO CARA OCULTA | 3d | 2025-05-24 | 2025-05-27 | A3570 | 29d | 0d |
| A3600 |  | ACERO FY=4200 KG/CM2, GRADO 60 | 3d | 2025-05-24 | 2025-05-27 | A3590 FF | 29d | 0d |
|  | 5 | **Instalaciones Hidráulicas** |  | 2025-05-28 | 2025-05-28 |  |  |  |
| A3610 |  | JUNTA DE DILATACIÓN | 1d | 2025-05-28 | 2025-05-28 | A3580 | 29d |  |
|  | 6 | **Señalización** |  | 2025-06-05 | 2025-07-01 |  |  |  |
|  | 1 | **Señalización Vertical** |  | 2025-06-05 | 2025-06-16 |  |  |  |
| A3620 |  | SUMINISTRO E INSTALACIÓN DE SEÑALES | 5d | 2025-06-05 | 2025-06-10 | A2450 | 0d |  |
| A3630 |  | TUBOS DE SOPORTE | 3d | 2025-06-11 | 2025-06-13 | A3620 | 0d |  |
| A3640 |  | SEÑALES EN PÓRTICO | 1d | 2025-06-14 | 2025-06-14 | A3630 | 0d |  |
| A3650 |  | MARCADORES EN ZONAS SINGULARES | 1d | 2025-06-16 | 2025-06-16 | A3640 | 0d |  |
|  | 2 | **Señalización Horizontal** |  | 2025-06-17 | 2025-06-28 |  |  |  |
| A3660 |  | MARCAS EN EL PAVIMENTO A=0.15 M(02 MANOS) | 5d | 2025-06-17 | 2025-06-21 | A3650 | 0d |  |
| A3670 |  | SUMINISTRO E INSTALACION DE TACHONES ROJOS | 2d | 2025-06-23 | 2025-06-24 | A3660 | 0d |  |
| A3680 |  | DEMARCACIÓN DE SEÑALES Y SÍMBOLOS EN EL PAVIMENTO | 1d | 2025-06-25 | 2025-06-25 | A3670 | 0d |  |
| A3690 |  | PINTURA EN SARDINEL | 3d | 2025-06-26 | 2025-06-28 | A3680 | 0d |  |

| ID | WBS | Activity | Duration | Start | Finish | Predecessors | Total float | Free float |
| --- | --- | --- | --- | --- | --- | --- | --- | --- |
|  | 3 | **Seguridad Vial** |  | 2025-06-30 | 2025-07-01 |  |  |  |
| A3700 |  | MARCADORES EN ZONAS SINGULARES | 1d | 2025-06-30 | 2025-06-30 | A3690 | 0d |  |
| A3710 |  | POSTES DELINEADORES | 1d | 2025-07-01 | 2025-07-01 | A3700 | 0d |  |
|  | 7 | **Transportes** |  | 2024-07-06 | 2025-05-29 |  |  |  |
| A1410 |  | Transporte de material orgánico (a DMO) D<=1km | 20d | 2024-07-06 | 2024-07-29 | A1190 | 264d | 0d |
| A1430 |  | Transporte de material excedente D<= 1km | 125d | 2024-07-13 | 2024-12-05 | A1180 | 28d | 0d |
| A1420 |  | Transporte de material orgánico (a DMO) D>1km | 25d | 2024-07-30 | 2024-08-27 | A1410 | 264d |  |
| A1470 |  | Transporte de roca D<=1km | 30d | 2024-09-14 | 2024-10-18 | A2320 | 39d | 0d |
| A1490 |  | Transporte de material de préstamo cantera de rio (cuerpo de terraplén) D<=1km | 40d | 2024-09-14 | 2024-10-30 | A2320 | 139d | 0d |
| A1450 |  | Transporte de material de prestamo (afirmado) D<= 1km | 10d | 2024-09-24 | 2024-10-04 | A1200 | 221d | 0d |
| A1460 |  | Transporte de material de prestamo (afirmado) D> 1km | 10d | 2024-10-05 | 2024-10-16 | A1450 | 221d |  |
| A1480 |  | Transporte de roca D>1km | 180d | 2024-10-19 | 2025-05-16 | A1470 | 39d |  |
| A1500 |  | Transporte de material de préstamo cantera de rio (cuerpo de terraplén) D>1km | 70d | 2024-10-31 | 2025-01-20 | A1490 | 139d |  |
| A1440 |  | Transporte de material excedente D> 1km | 150d | 2024-12-06 | 2025-05-29 | A1430 | 28d |  |
|  | 8 | **Muros de Contención** |  | 2025-05-15 | 2025-05-30 |  |  |  |
|  | 1 | **Obras de Concreto Simple** |  | 2025-05-15 | 2025-05-19 |  |  |  |
| A3720 |  | CONCRETO CLASE F(F'C=100 KG/CM2) | 4d | 2025-05-15 | 2025-05-19 | A3560 | 0d |  |
|  | 2 | **Obras de Concreto Armado** |  | 2025-05-20 | 2025-05-26 |  |  |  |
| A3730 |  | CONCRETO CLASE A (F'C=280 KG/CM2) | 6d | 2025-05-20 | 2025-05-26 | A3750 FF | 0d |  |
| A3740 |  | ENCOFRADO Y DESENCOFRADO | 6d | 2025-05-20 | 2025-05-26 | A3720 | 0d |  |
| A3750 |  | ACERO FY=4200 KG/CM2, GRADO 60 | 6d | 2025-05-20 | 2025-05-26 | A3740 FF | 0d |  |
| A3760 |  | BARRERA DE SEGURIDAD RIGIDA TIPO NEW JERSEY PREFABRICADA | 6d | 2025-05-20 | 2025-05-26 | A3730 FF | 27d | 0d |
|  | 3 | **Arquitectura** |  | 2025-05-27 | 2025-05-30 |  |  |  |
| A3770 |  | PINTURA BITUMINOSA | 4d | 2025-05-27 | 2025-05-30 | A3760 | 27d |  |

| ID | WBS | Activity | Duration | Start | Finish | Predecessors | Total float | Free float |
| --- | --- | --- | --- | --- | --- | --- | --- | --- |
|  | 9 | **Pavimento Rígido** |  | 2025-05-27 | 2025-06-24 |  |  |  |
| A1990 |  | PAVIMENTO HIDRAULICO (F'C 300KG/CM2) | 8d | 2025-05-27 | 2025-06-04 | A2020 FF | 0d |  |
| A2000 |  | ACERO FY=4200 KG/CM2, GRADO 60 | 8d | 2025-05-27 | 2025-06-04 | A2010 FF | 0d |  |
| A2010 |  | ENCOFRADO Y DESENCOFRADO DE PAVIMENTOS | 8d | 2025-05-27 | 2025-06-04 | A3730 | 0d |  |
| A2020 |  | ACERO LONGITUDINAL, TRANSVERSAL Y DOWELLS | 8d | 2025-05-27 | 2025-06-04 | A2000 FF | 0d |  |
| A2390 |  | CONCRETO CLASE A (F'C=280 KG/CM2) - LOSAS | 8d | 2025-05-27 | 2025-06-04 | A1990 FF | 0d |  |
| A2450 |  | PAVIMENTO DE CONCRETO ASFALTO EN FRIO | 8d | 2025-05-27 | 2025-06-04 | A2390 FF | 0d |  |
| A2400 |  | JUNTA TRANSVERSAL DE CONTRACCIÓN | 10d | 2025-06-05 | 2025-06-16 | A2450 | 6d | 0d |
| A2420 |  | JUNTA DE AISLAMIENTO | 7d | 2025-06-17 | 2025-06-24 | A2400 | 6d |  |
|  | 10 | **Paso Superior tipo Marco** |  | 2025-06-05 | 2025-06-26 |  |  |  |
|  | 1 | **Obras de Concreto Simple** |  | 2025-06-05 | 2025-06-06 |  |  |  |
| A3780 |  | CONCRETO CLASE F(F'C=100 KG/CM2) | 2d | 2025-06-05 | 2025-06-06 | A3790 FF | 4d | 0d |
| A3790 |  | ENCOFRADO Y DESENCOFRADO EN ESTRUCTURAS | 2d | 2025-06-05 | 2025-06-06 | A2450 | 4d | 0d |
|  | 2 | **Obras de Concreto Armado** |  | 2025-06-07 | 2025-06-17 |  |  |  |
| A2190 |  | CONCRETO CLASE A (F'C=280 KG/CM2) | 5d | 2025-06-07 | 2025-06-12 | A2220 FF | 4d | 0d |
| A2200 |  | ENCOFRADO Y DESENCOFRADO | 5d | 2025-06-07 | 2025-06-12 | A3780 | 4d | 0d |
| A2210 |  | ACERO FY=4200 KG/CM2, GRADO 60 | 5d | 2025-06-07 | 2025-06-12 | A2200 FF | 4d | 0d |
| A2220 |  | GEOCOMPUESTO DE DRENAJE | 5d | 2025-06-07 | 2025-06-12 | A2210 FF | 4d | 0d |
| A2230 |  | TUBO PVC | 5d | 2025-06-07 | 2025-06-12 | A2220 FF | 16d |  |
| A2240 |  | BARANDAS METÁLICAS | 4d | 2025-06-13 | 2025-06-17 | A2190 | 12d |  |
| A2250 |  | JUNTAS DE DILATACIÓN | 2d | 2025-06-13 | 2025-06-14 | A2190 | 4d | 0d |
|  | 3 | **Arquitectura** |  | 2025-06-16 | 2025-06-26 |  |  |  |
| A3800 |  | PINTURA BITUMINOSA | 10d | 2025-06-16 | 2025-06-26 | A2250 | 4d |  |
|  | 11 | **Infraestructura Verde y Paisajismo** |  | 2024-07-06 | 2024-10-12 |  |  |  |
|  | 1 | **Preparación del Terreno** |  | 2024-07-06 | 2024-07-17 |  |  |  |
| A3810 |  | UBICACIÓN Y DELIMITACIÓN DE LA ZONA DE TRABAJO | 3d | 2024-07-06 | 2024-07-09 | A1140 | 224d | 0d |
| A3820 |  | TRAZADO, MARCACIÓN Y ESTACADO | 2d | 2024-07-10 | 2024-07-11 | A3810 | 224d | 0d |
| A3830 |  | PREPARACIÓN Y APORTE DEL SUSTRATO | 2d | 2024-07-12 | 2024-07-13 | A3820 | 224d | 0d |
| A3840 |  | RIEGO DE ÁREAS VEGETADAS CON CAMIÓN CISTERNA | 3d | 2024-07-15 | 2024-07-17 | A3830 | 224d | 0d |

| ID | WBS | Activity | Duration | Start | Finish | Predecessors | Total float | Free float |
| --- | --- | --- | --- | --- | --- | --- | --- | --- |
|  | 2 | **Especies Arbóreas** |  | 2024-07-20 | 2024-08-12 |  |  |  |
| A3850 |  | PLANTACIÓN DE ÁRBOLES | 20d | 2024-07-20 | 2024-08-12 | A3910 | 224d | 0d |
|  | 3 | **Especies Arbustivas** |  | 2024-08-13 | 2024-09-21 |  |  |  |
| A3860 |  | PLANTACIÓN DE ARBUSTOS | 35d | 2024-08-13 | 2024-09-21 | A3850 | 224d | 0d |
|  | 4 | **Elementos Arquitectónicos** |  | 2024-10-02 | 2024-10-12 |  |  |  |
| A3870 |  | BARANDAS RÚSTICAS DE MADERA | 10d | 2024-10-02 | 2024-10-12 | A3880 | 224d |  |
|  | 5 | **Obras de Concreto Simple** |  | 2024-09-25 | 2024-10-03 |  |  |  |
| A3900 |  | ENCOFRADO Y DESENCOFRADO | 2d | 2024-09-25 | 2024-09-26 | A3920 | 224d | 0d |
| A3890 |  | CONCRETO CLASE A (f'c=280 kg/cm2) | 2d | 2024-09-27 | 2024-09-28 | A3900 | 224d | 0d |
| A3880 |  | EMBOQUILLADO DE PIEDRA | 2d | 2024-09-30 | 2024-10-01 | A3890 | 224d | 0d |
| A3930 |  | JUNTA DE DILATACIÓN | 2d | 2024-10-02 | 2024-10-03 | A3880 | 232d |  |
|  | 6 | **Movimiento de Tierras** |  | 2024-07-18 | 2024-09-24 |  |  |  |
| A3910 |  | CORTE | 2d | 2024-07-18 | 2024-07-19 | A3840 | 224d | 0d |
| A3920 |  | RELLENO | 2d | 2024-09-23 | 2024-09-24 | A3860 | 224d | 0d |
